# Impreza integracyjna

Schedule from MS Project, 2003-01-01 to 2003-02-06, status date 2003-02-15.
Przygotowanie imprezy firmowej dla pracowników
ABC sp. z o.o.

## Calendars

- Firmowy: Mon-Fri 08:00-16:00; Sat-Sun off. Exceptions (off unless hours are given): 2003-01-01, 2003-01-18 08:00-16:00, 2003-02-01 16:00-24:00.

## Schedule

| ID | WBS | Task | Type | Duration | Start | Finish | Predecessors | Total slack | Free slack | Constraint | Work |
| --- | --- | --- | --- | --- | --- | --- | --- | --- | --- | --- | --- |
| 1 | 1 | Start | milestone | 0d | 2003-01-01 08:00 | 2003-01-01 08:00 |  | 2d | 0d |  |  |
| 2 | 2 | **Faza wstępna** |  | 7.5d | 2003-01-02 08:00 | 2003-01-13 12:00 |  | 1.62d |  |  | 20h |
| 3 | 2.1 | Wyznaczenie osób odpowiedzialnych |  | 1d | 2003-01-02 08:00 | 2003-01-02 16:00 | 1 | 2d | 0d |  |  |
| 4 | 2.2 | Ustalenie programu imprezy |  | 1d | 2003-01-03 08:00 | 2003-01-03 16:00 | 3 | 2d | 0d |  |  |
| 5 | 2.3 | Poszukiwanie zespołu muzycznego |  | 0.49w | 2003-01-06 08:00 | 2003-01-08 12:00 | 4 | 2d | 0d |  |  |
| 6 | 2.4 | Wybór lokalizacji |  | 0.49w | 2003-01-08 12:00 | 2003-01-10 16:00 | 5SS | 1.62d | 0d |  | 20h |
| 7 | 2.5 | Ustalenie menu |  | 0.5d | 2003-01-13 08:00 | 2003-01-13 12:00 | 6 | 1.62d | 0d |  |  |
| 8 | 3 | **Przygotowanie bezpośrednie** |  | 15.5d | 2003-01-13 12:00 | 2003-01-31 16:00 |  | 0d |  |  |  |
| 9 | 3.1 | Potwierdzenie lokalizacji i menu |  | 0.5d | 2003-01-13 12:00 | 2003-01-13 16:00 | 7 | 1.62d | 0d |  |  |
| 10 | 3.2 | Rozesłanie zaproszeń |  | 5d | 2003-01-14 08:00 | 2003-01-18 16:00 | 5, 9 | 1.62d | 0d |  |  |
| 11 | 3.3 | Przyjmowanie potwierdzeń |  | 1.95w | 2003-01-17 08:00 | 2003-01-29 16:00 | 10FS-2d | 1.62d |  |  |  |
| 12 | 3.4 | Przyjęcie lokalu |  | 3h | 2003-01-31 13:00 | 2003-01-31 16:00 | 11 | 0d |  | as late as possible |  |
| 13 | 4 | **Impreza integracyjna** |  | 1d | 2003-02-01 08:00 | 2003-02-02 00:00 |  | 0d |  |  |  |
| 14 | 4.1 | Przywitanie |  | 0.5h | 2003-02-01 08:00 | 2003-02-01 16:30 | 12, 11 | 0d |  | must start on 2003-02-01 08:00 |  |
| 15 | 4.2 | Obiad |  | 1h | 2003-02-01 16:30 | 2003-02-01 17:30 | 14 | 0d |  |  |  |
| 16 | 4.3 | Mecz piłki nożnej |  | 2h | 2003-02-01 17:30 | 2003-02-01 19:30 | 15 | 0d |  |  |  |
| 17 | 4.4 | Turniej kręgli |  | 1.5h | 2003-02-01 17:30 | 2003-02-01 19:00 | 15 | 0.06d |  |  |  |
| 18 | 4.5 | Kiełbaski i piwo |  | 3h | 2003-02-01 19:30 | 2003-02-01 22:30 | 16, 17 | 0d |  |  |  |
| 19 | 4.6 | Koncert |  | 1.5h | 2003-02-01 22:30 | 2003-02-02 00:00 | 17, 18 | 0d |  |  |  |
| 20 | 4.7 | Pokaz sztucznych ogni |  | 0.5h | 2003-02-01 23:30 | 2003-02-02 00:00 | 19FF | 0d |  |  |  |
| 21 | 5 | **Zakończenie** |  | 3.38d | 2003-02-03 08:00 | 2003-02-06 11:00 |  | 0d |  |  |  |
| 22 | 5.1 | Czynności porządkowe |  | 1d | 2003-02-03 08:00 | 2003-02-03 16:00 | 20, 18 | 2d |  |  |  |
| 23 | 5.2 | Ustalenie szkód |  | 1d | 2003-02-03 08:00 | 2003-02-03 16:00 | 20 | 0d |  |  |  |
| 24 | 5.3 | Naprawa szkód |  | 1d | 2003-02-05 08:00 | 2003-02-05 16:00 | 23FS+1d | 0d |  |  |  |
| 25 | 5.4 | Zdanie lokalu |  | 3h | 2003-02-06 08:00 | 2003-02-06 11:00 | 24, 22 | 0d |  |  |  |

| ID | WBS | Task | Type | Duration | Start | Finish | Predecessors | Total slack | Constraint |
| --- | --- | --- | --- | --- | --- | --- | --- | --- | --- |
| 26 | 6 | **Artykuły w gazetce zakładowej** |  | 23d | 2003-01-06 08:00 | 2003-02-03 16:00 |  | 2.38d |  |
| 27 | 6.1 | Artykuły w gazetce zakładowej 1 |  | 1d | 2003-01-06 08:00 | 2003-01-06 16:00 |  | 24.38d | start no earlier than 2003-01-06 08:00 |
| 28 | 6.2 | Artykuły w gazetce zakładowej 2 |  | 1d | 2003-01-20 08:00 | 2003-01-20 16:00 |  | 13.38d | start no earlier than 2003-01-20 08:00 |
| 29 | 6.3 | Artykuły w gazetce zakładowej 3 |  | 1d | 2003-02-03 08:00 | 2003-02-03 16:00 |  | 2.38d | start no earlier than 2003-02-03 08:00 |
| 30 | 7 | Koniec | milestone | 0d | 2003-02-06 11:00 | 2003-02-06 11:00 | 25 | 0d |  |
