# Budowa i zmiana lokalizacji

Schedule from MS Project, 2012-04-02 to 2013-06-26.
Przeprowadzka firmy do nowo wybudowanej siedziby
Firma sp z.o.

## Calendars

- Kalendarz firmowy Firma sp. z o.o.: Mon-Fri 08:00-16:00; Sat-Sun off. Exceptions (off unless hours are given): 2012-01-01 to 2021-01-01 (Nowy Rok, recurring), 2012-04-09 (Poniedziałek Wielkanocny), 2012-05-01 to 2021-05-01 (Święto Pracy, recurring), 2012-05-03 to 2021-05-03 (Święto Konstytucji 3 maja, recurring), 2012-06-07 (Boże Ciało), 2012-08-15 to 2021-08-15 (Święto Wojska Polskiego, recurring), 2012-11-01 to 2021-11-01 (Wszystkich Świętych, recurring), 2012-11-11 to 2021-11-11 (Święto Niepodległości, recurring), 2012-12-25 to 2021-12-25 (Boże Narodzienie (pierwszy dzień), recurring), 2012-12-26 (Boże Narodzenie (drugi dzień)).

## Schedule

| ID | WBS | Task | Type | Duration | Start | Finish | Predecessors | Total slack | Free slack |
| --- | --- | --- | --- | --- | --- | --- | --- | --- | --- |
| 1 | 1 | Start | milestone | 0d | 2012-04-02 | 2012-04-02 |  | 0d |  |
| 2 | 2 | **Analiza potrzeb** |  | 2d | 2012-04-02 | 2012-04-04 |  | 0d |  |
| 3 | 2.1 | Opracowanie i rozesłanie ankiet |  | 1d | 2012-04-02 | 2012-04-03 | 1 | 0d |  |
| 4 | 2.2 | Opracowanie zestawienia z wyników ankiet |  | 1d | 2012-04-03 | 2012-04-04 | 3 | 0d |  |
| 5 | 2.3 | Analiza potrzeb zakończona | milestone | 0d | 2012-04-04 | 2012-04-04 | 4 | 0d |  |
| 6 | 3 | **Wybór wykonawców** |  | 19.5d? | 2012-04-04 | 2012-05-04 |  | 0d |  |
| 7 | 3.1 | Przygotowanie treści zapytania ofertowego i rozesłanie zapytań do potencjalnych wykonawców |  | 15d? | 2012-04-04 | 2012-04-26 | 5 | 0d |  |
| 8 | 3.2 | Udzielenie odpowiedzi na pytania wykonawców |  | 2d | 2012-04-26 | 2012-04-30 | 7 | 289.5d | 0d |
| 9 | 3.3 | Zakończenie składania ofert | milestone | 0d | 2012-04-30 | 2012-04-30 | 8 | 289.5d | 0d |
| 10 | 3.4 | Ocena ofert i wyłonienie wykonawcy |  | 2d | 2012-04-30 | 2012-05-04 | 9 | 289.5d | 0d |
| 11 | 3.5 | Podpisanie umowy |  | 0.5d | 2012-05-04 | 2012-05-04 | 10 | 289.5d | 0d |
| 12 | 3.6 | Wybór wykonawców zakończony | milestone | 0d | 2012-05-04 | 2012-05-04 | 11 | 289.5d |  |
| 13 | 4 | **Budowa nowej siedziby** |  | 296.25d? | 2012-04-04 | 2013-06-07 |  | 0d |  |
| 14 | 4.1 | Opracowanie i złożenie wniosków o wydanie zezwoleń |  | 7d? | 2012-04-04 | 2012-04-16 | 7SS, 12 | 0d |  |
| 15 | 4.2 | Odbiór zezwoleń |  | 2h | 2012-04-16 | 2012-04-16 | 14 | 0d |  |
| 16 | 4.3 | **Budowa** |  | 220d | 2012-04-16 | 2013-02-28 |  | 0d |  |
| 17 | 4.3.1 | Etap I - Prace ziemne |  | 1mo | 2012-04-16 | 2012-05-16 | 15 | 0d |  |
| 18 | 4.3.2 | Etap II - Kontrukcja budynku i elewacje |  | 4mo | 2012-05-16 | 2012-09-07 | 17 | 0d |  |
| 19 | 4.3.3 | Etap III - Prace wykończeniowe i inne |  | 6mo | 2012-09-07 | 2013-02-28 | 18 | 0d |  |
| 20 | 4.4 | **Aranżacja i wyposażanie** |  | 287d | 2012-04-16 | 2013-06-05 |  | 0d |  |
| 21 | 4.4.1 | Wykonanie projektu |  | 10d | 2012-04-16 | 2012-04-30 | 15 | 205.5d | 0d |
| 22 | 4.4.2 | Rozesłanie zapytań do potencjalnych wykonawców |  | 4h | 2012-04-30 | 2012-04-30 | 21 | 205.5d | 0d |
| 23 | 4.4.3 | Udzielanie odpowiedzi na pytania potencjalnych wykonawców |  | 2d | 2012-04-30 | 2012-05-04 | 22 | 205.5d | 0d |
| 24 | 4.4.4 | Wybór wykonawcy i podpisanie umowy |  | 2d | 2012-05-04 | 2012-05-08 | 23 | 205.5d |  |

| ID | WBS | Task | Type | Duration | Start | Finish | Predecessors | Total slack |
| --- | --- | --- | --- | --- | --- | --- | --- | --- |
| 25 | 4.4.5 | **Prace aranżacyjno wykończeniowe** |  | 67d | 2013-02-28 | 2013-06-05 |  | 0d |
| 26 | 4.4.5.1 | Aranżacje |  | 3mo | 2013-02-28 | 2013-05-27 | 24, 19 | 0d |
| 27 | 4.4.5.2 | Zakup sprzętu |  | 2d | 2013-05-27 | 2013-05-29 | 26 | 0d |
| 28 | 4.4.5.3 | Dostawa i montaż |  | 5d | 2013-05-29 | 2013-06-05 | 27 | 0d |
| 29 | 4.4.5.4 | Prace aranżacyjno wykończeniowe zakończone | milestone | 0d | 2013-06-05 | 2013-06-05 | 28 | 0d |
| 30 | 4.5 | Odbiór budynku |  | 2d | 2013-06-05 | 2013-06-07 | 29 | 0d |
| 31 | 4.6 | Budowa zakończona | milestone | 0d | 2013-06-07 | 2013-06-07 | 30 | 0d |
| 32 | 5 | **Przygotowanie do przeprowadzki** |  | 7d | 2013-06-07 | 2013-06-18 |  | 0d |
| 33 | 5.1 | Stworzenie planu przeprowadzki |  | 3d | 2013-06-07 | 2013-06-12 | 31 | 0d |
| 34 | 5.2 | Pozyskanie firmy przeprowadzkowej |  | 4d | 2013-06-12 | 2013-06-18 | 33 | 0d |
| 35 | 5.3 | Przygotowanie do przeprowadzki zakończone | milestone | 0d | 2013-06-18 | 2013-06-18 | 34 | 0d |
| 36 | 6 | **Przeprowadzka** |  | 5.75d | 2013-06-18 | 2013-06-26 |  | 0d |
| 37 | 6.1 | **Prace w starej siedzibie** |  | 2.5d | 2013-06-18 | 2013-06-20 |  | 0d |
| 38 | 6.1.1 | Pakowanie i demontaż |  | 1d | 2013-06-18 | 2013-06-19 | 35 | 0d |
| 39 | 6.1.2 | Załadunek i transport |  | 4h | 2013-06-19 | 2013-06-19 | 38 | 0d |
| 40 | 6.1.3 | Demontaż infrastruktury teleinformatyczne |  | 6h | 2013-06-19 | 2013-06-20 | 39 | 0d |
| 41 | 6.1.4 | Transport infrastruktury teleinformatycznej |  | 2h | 2013-06-20 | 2013-06-20 | 40 | 0d |
| 42 | 6.1.5 | Prace w starej siedzibie zakończone | milestone | 0d | 2013-06-20 | 2013-06-20 | 41 | 0d |
| 43 | 6.2 | **Prace w nowej siedzibie** |  | 3.25d | 2013-06-20 | 2013-06-26 |  | 0d |
| 44 | 6.2.1 | Rozładunek |  | 2h | 2013-06-20 | 2013-06-21 | 42 | 0d |
| 45 | 6.2.2 | Rozpakowanie i ustawianie wyposażanie |  | 1d | 2013-06-21 | 2013-06-24 | 44 | 0d |
| 46 | 6.2.3 | Montaż i uruchomienie infrastruktury teleinformatycznej |  | 16h | 2013-06-24 | 2013-06-26 | 45 | 0d |
| 47 | 6.2.4 | Prace w nowej siedzibie zakończone | milestone | 0d | 2013-06-26 | 2013-06-26 | 46 | 0d |
| 48 | 7 | Koniec | milestone | 0d | 2013-06-26 | 2013-06-26 | 47 | 0d |
