# Budowa i zmiana lokalizacji

Schedule from MS Project, 2012-04-02 to 2013-08-06.
Przeprowadzka firmy do nowo wybudowanej siedziby
Firma sp z.o.

## Calendars

- Kalendarz firmowy Firma sp. z o.o.: Mon-Fri 08:00-16:00; Sat-Sun off. Exceptions (off unless hours are given): 2012-01-01 to 2021-01-01 (Nowy Rok, recurring), 2012-04-09 (Poniedziałek Wielkanocny), 2012-05-01 to 2021-05-01 (Święto Pracy, recurring), 2012-05-03 to 2021-05-03 (Święto Konstytucji 3 maja, recurring), 2012-06-07 (Boże Ciało), 2012-08-15 to 2021-08-15 (Święto Wojska Polskiego, recurring), 2012-11-01 to 2021-11-01 (Wszystkich Świętych, recurring), 2012-11-11 to 2021-11-11 (Święto Niepodległości, recurring), 2012-12-25 to 2021-12-25 (Boże Narodzienie (pierwszy dzień), recurring), 2012-12-26 (Boże Narodzenie (drugi dzień)).

## Resources

| Resource | Group | Unit | Rate |
| --- | --- | --- | --- |
| Katarzyna Kalka | Pracownik administracyjny |  | 33 |
| Sebastian Wilczewski | Kierownik projektu |  | 80 |
| Andrzej Sójka | Dział radców prawnych |  | 110 |
| Piotr Krauze | Zarząd |  | 130 |
| Władysław Lis | Pracownik administracyjny |  | 30 |
| ArchiTekt | Firma zewnętrzna |  |  |
| Budmor | Firma zewnętrzna |  |  |
| DekorArt | Firma zewnętrzna |  |  |
| Super AGD | Firma zewnętrzna |  |  |
| Heros | Firma zewnętrzna |  |  |
| Maciej Klos | Dział informatyki |  | 45 |
| Kawa | Materiały pomocnicze | kubek | 2 |
| Bułki | Materiały pomocnicze | szt. | 3.5 |

## Schedule

| ID | WBS | Task | Type | Duration | Start | Finish | Predecessors | Total slack | Free slack | Constraint |
| --- | --- | --- | --- | --- | --- | --- | --- | --- | --- | --- |
| 1 | Budowa i zmiana lokalizacji-** | Start | milestone | 0d | 2012-04-02 09:00 | 2012-04-02 09:00 |  | 0d |  |  |
| 2 | Budowa i zmiana lokalizacji-** | **Analiza potrzeb** |  | 9d | 2012-04-02 09:00 | 2012-04-16 09:00 |  | 0d |  |  |
| 3 | Budowa i zmiana lokalizacji-**.01 | Opracowanie i rozesłanie ankiet |  | 1d | 2012-04-02 09:00 | 2012-04-03 09:00 | 1 | 0d |  |  |
| 4 | Budowa i zmiana lokalizacji-**.02 | Opracowanie zestawienia z wyników ankiet |  | 1d | 2012-04-13 09:00 | 2012-04-16 09:00 | 3FS+7d | 0d |  |  |
| 5 | Budowa i zmiana lokalizacji-**.03 | Analiza potrzeb zakończona | milestone | 0d | 2012-04-16 09:00 | 2012-04-16 09:00 | 4 | 0d |  |  |
| 6 | Budowa i zmiana lokalizacji-** | **Wybór wykonawców** |  | 29.5d? | 2012-04-16 09:00 | 2012-05-29 13:00 |  | 0d |  |  |
| 7 | Budowa i zmiana lokalizacji-**.01 | Przygotowanie treści zapytania ofertowego i rozesłanie zapytań do potencjalnych wykonawców |  | 15d? | 2012-04-16 09:00 | 2012-05-09 09:00 | 5 | 0d |  |  |
| 8 | Budowa i zmiana lokalizacji-**.02 | Udzielenie odpowiedzi na pytania wykonawców |  | 2d | 2012-05-16 09:00 | 2012-05-18 09:00 | 7FS+5d | 7.75d | 0d |  |
| 9 | Budowa i zmiana lokalizacji-**.03 | Zakończenie składania ofert | milestone | 0d | 2012-05-23 09:00 | 2012-05-23 09:00 | 8FS+3d | 7.75d | 0d |  |
| 10 | Budowa i zmiana lokalizacji-**.04 | Ocena ofert i wyłonienie wykonawcy |  | 2d | 2012-05-23 09:00 | 2012-05-25 09:00 | 9 | 7.75d | 0d |  |
| 11 | Budowa i zmiana lokalizacji-**.05 | Podpisanie umowy |  | 0.5d | 2012-05-29 09:00 | 2012-05-29 13:00 | 10FS+2d | 7.75d | 0d | finish no later than 2012-06-30 16:00 |
| 12 | Budowa i zmiana lokalizacji-**.06 | Wybór wykonawców zakończony | milestone | 0d | 2012-05-29 13:00 | 2012-05-29 13:00 | 11 | 7.75d |  |  |
| 13 | Budowa i zmiana lokalizacji-** | **Budowa nowej siedziby** |  | 322.25d? | 2012-04-16 09:00 | 2013-07-24 11:00 |  | 0d |  |  |
| 14 | Budowa i zmiana lokalizacji-**.01 | Opracowanie i złożenie wniosków o wydanie zezwoleń |  | 7d? | 2012-04-16 09:00 | 2012-04-25 09:00 | 7SS, 12 | 0d |  |  |
| 15 | Budowa i zmiana lokalizacji-**.02 | Odbiór zezwoleń |  | 2h | 2012-06-11 09:00 | 2012-06-11 11:00 | 14FS+30d | 0d |  |  |
| 16 | Budowa i zmiana lokalizacji-**.03 | **Budowa** |  | 204d | 2012-06-11 11:00 | 2013-03-29 11:00 |  | 0d |  |  |
| 17 | Budowa i zmiana lokalizacji-**.03.01 | Etap I - Prace ziemne |  | 1mo | 2012-06-11 11:00 | 2012-07-09 11:00 | 15, 12 | 0d |  | finish no later than 2012-11-01 16:00 |
| 18 | Budowa i zmiana lokalizacji-**.03.02 | Etap II - Konstrukcja budynku i elewacje |  | 4mo | 2012-07-09 11:00 | 2012-10-30 11:00 | 17 | 0d |  |  |
| 19 | Budowa i zmiana lokalizacji-**.03.03 | Etap III - Prace wykończeniowe i inne |  | 6mo | 2012-10-08 11:00 | 2013-03-29 11:00 | 18FS-2% | 0d |  |  |
| 20 | Budowa i zmiana lokalizacji-**.04 | **Aranżacja i wyposażanie** |  | 283d | 2012-06-11 11:00 | 2013-07-22 11:00 |  | 0d |  |  |
| 21 | Budowa i zmiana lokalizacji-**.04.01 | Wykonanie projektu |  | 10d | 2012-06-11 11:00 | 2012-06-25 11:00 | 15 | 187.5d | 0d |  |
| 22 | Budowa i zmiana lokalizacji-**.04.02 | Rozesłanie zapytań do potencjalnych wykonawców |  | 4h | 2012-06-25 11:00 | 2012-06-25 15:00 | 21 | 187.5d | 0d |  |
| 23 | Budowa i zmiana lokalizacji-**.04.03 | Udzielanie odpowiedzi na pytania potencjalnych wykonawców |  | 2d | 2012-06-25 15:00 | 2012-06-27 15:00 | 22 | 187.5d | 0d |  |
| 24 | Budowa i zmiana lokalizacji-**.04.04 | Wybór wykonawcy i podpisanie umowy |  | 2d | 2012-06-29 15:00 | 2012-07-03 15:00 | 23FS+2d | 187.5d |  |  |

Notes:
- 3: W ankiecie należy uwzględnić takie zagadnienia jak: / ·Powierzchnia biurowa / ·Klimatyzacja / ·Dostępność miejsc parkingowych / ·Nasłonecznienie

| ID | WBS | Task | Type | Duration | Start | Finish | Predecessors | Total slack | Free slack | Constraint | Deadline |
| --- | --- | --- | --- | --- | --- | --- | --- | --- | --- | --- | --- |
| 25 | Budowa i zmiana lokalizacji-**.04.05 | **Prace aranżacyjno wykończeniowe** |  | 79d | 2013-03-29 11:00 | 2013-07-22 11:00 |  | 0d |  |  |  |
| 26 | Budowa i zmiana lokalizacji-**.04.05.AA | Aranżacje |  | 3mo | 2013-03-29 11:00 | 2013-06-25 11:00 | 24, 19 | 0d |  |  |  |
| 27 | Budowa i zmiana lokalizacji-**.04.05.AB | Zakup sprzętu |  | 2d | 2013-06-21 11:00 | 2013-06-25 11:00 | 26FF | 0d |  |  |  |
| 28 | Budowa i zmiana lokalizacji-**.04.05.AC | Dostawa i montaż |  | 5d | 2013-07-15 11:00 | 2013-07-22 11:00 | 27FS+14d | 0d |  |  |  |
| 29 | Budowa i zmiana lokalizacji-**.04.05.AD | Prace aranżacyjno wykończeniowe zakończone | milestone | 0d | 2013-07-22 11:00 | 2013-07-22 11:00 | 28 | 0d |  |  |  |
| 30 | Budowa i zmiana lokalizacji-**.05 | Odbiór budynku |  | 2d | 2013-07-22 11:00 | 2013-07-24 11:00 | 29 | 0d |  |  |  |
| 31 | Budowa i zmiana lokalizacji-**.06 | Budowa zakończona | milestone | 0d | 2013-07-24 11:00 | 2013-07-24 11:00 | 30 | 0d |  |  | 2013-07-31 16:00 |
| 32 | Budowa i zmiana lokalizacji-** | **Przygotowanie do przeprowadzki** |  | 4d | 2013-07-23 11:00 | 2013-07-29 11:00 |  | 0d |  |  |  |
| 33 | Budowa i zmiana lokalizacji-**.01 | Stworzenie planu przeprowadzki |  | 3d | 2013-07-24 11:00 | 2013-07-29 11:00 | 31 | 0d |  |  |  |
| 34 | Budowa i zmiana lokalizacji-**.02 | Pozyskanie firmy przeprowadzkowej |  | 4d | 2013-07-23 11:00 | 2013-07-29 11:00 | 33FF | 0d |  |  |  |
| 35 | Budowa i zmiana lokalizacji-**.03 | Przygotowanie do przeprowadzki zakończone | milestone | 0d | 2013-07-29 11:00 | 2013-07-29 11:00 | 34 | 0d |  |  |  |
| 36 | Budowa i zmiana lokalizacji-** | **Przeprowadzka** |  | 4.75d | 2013-07-29 11:00 | 2013-08-05 09:00 |  | 0d |  |  |  |
| 37 | Budowa i zmiana lokalizacji-**.01 | **Prace w starej siedzibie** |  | 2.5d | 2013-07-29 11:00 | 2013-07-31 15:00 |  | 0d |  |  |  |
| 38 | Budowa i zmiana lokalizacji-**.01.01 | Pakowanie i demontaż |  | 1d | 2013-07-29 11:00 | 2013-07-30 11:00 | 35 | 0d |  |  |  |
| 39 | Budowa i zmiana lokalizacji-**.01.02 | Załadunek i transport |  | 4h | 2013-07-30 11:00 | 2013-07-30 15:00 | 38 | 0d |  |  |  |
| 40 | Budowa i zmiana lokalizacji-**.01.03 | Demontaż infrastruktury teleinformatyczne |  | 6h | 2013-07-30 15:00 | 2013-07-31 13:00 | 39 | 0.25d | 0d |  |  |
| 41 | Budowa i zmiana lokalizacji-**.01.04 | Transport infrastruktury teleinformatycznej |  | 2h | 2013-07-31 13:00 | 2013-07-31 15:00 | 40 | 0.25d | 0d |  |  |
| 42 | Budowa i zmiana lokalizacji-**.01.05 | Prace w starej siedzibie zakończone | milestone | 0d | 2013-07-31 15:00 | 2013-07-31 15:00 | 41 | 2.25d |  |  |  |
| 43 | Budowa i zmiana lokalizacji-**.02 | **Prace w nowej siedzibie** |  | 3.25d | 2013-07-30 15:00 | 2013-08-05 09:00 |  | 0d |  |  |  |
| 44 | Budowa i zmiana lokalizacji-**.02.01 | Rozładunek |  | 2h | 2013-07-30 15:00 | 2013-07-31 09:00 | 39, 42 | 0d |  |  |  |
| 45 | Budowa i zmiana lokalizacji-**.02.02 | Rozpakowanie i ustawianie wyposażanie |  | 1d | 2013-07-31 09:00 | 2013-08-01 09:00 | 44 | 0d |  |  |  |
| 46 | Budowa i zmiana lokalizacji-**.02.03 | Montaż i uruchomienie infrastruktury teleinformatycznej |  | 16h | 2013-08-01 09:00 | 2013-08-05 09:00 | 45, 41 | 0d |  |  |  |
| 47 | Budowa i zmiana lokalizacji-**.02.04 | Prace w nowej siedzibie zakończone | milestone | 0d | 2013-08-05 09:00 | 2013-08-05 09:00 | 46, 42 | 0d |  |  |  |
| 48 | Budowa i zmiana lokalizacji-** | **Przygotowanie raportu** |  | 289.25d | 2012-04-06 09:00 | 2013-05-31 11:00 |  | 45.75d |  |  |  |
| 49 | Budowa i zmiana lokalizacji-**.01 | Przygotowanie raportu 1 |  | 2h | 2012-04-06 09:00 | 2012-04-06 11:00 |  | 334.75d |  | start no earlier than 2012-04-06 09:00 |  |
| 50 | Budowa i zmiana lokalizacji-**.02 | Przygotowanie raportu 2 |  | 2h | 2012-04-13 09:00 | 2012-04-13 11:00 |  | 330.75d |  | start no earlier than 2012-04-13 09:00 |  |
| 51 | Budowa i zmiana lokalizacji-**.03 | Przygotowanie raportu 3 |  | 2h | 2012-04-20 09:00 | 2012-04-20 11:00 |  | 325.75d |  | start no earlier than 2012-04-20 09:00 |  |
| 52 | Budowa i zmiana lokalizacji-**.04 | Przygotowanie raportu 4 |  | 2h | 2012-04-27 09:00 | 2012-04-27 11:00 |  | 320.75d |  | start no earlier than 2012-04-27 09:00 |  |
| 53 | Budowa i zmiana lokalizacji-**.05 | Przygotowanie raportu 5 |  | 2h | 2012-05-04 09:00 | 2012-05-04 11:00 |  | 317.75d |  | start no earlier than 2012-05-04 09:00 |  |
| 54 | Budowa i zmiana lokalizacji-**.06 | Przygotowanie raportu 6 |  | 2h | 2012-05-11 09:00 | 2012-05-11 11:00 |  | 312.75d |  | start no earlier than 2012-05-11 09:00 |  |
| 55 | Budowa i zmiana lokalizacji-**.07 | Przygotowanie raportu 7 |  | 2h | 2012-05-18 09:00 | 2012-05-18 11:00 |  | 307.75d |  | start no earlier than 2012-05-18 09:00 |  |
| 56 | Budowa i zmiana lokalizacji-**.08 | Przygotowanie raportu 8 |  | 2h | 2012-05-25 09:00 | 2012-05-25 11:00 |  | 302.75d |  | start no earlier than 2012-05-25 09:00 |  |
| 57 | Budowa i zmiana lokalizacji-**.09 | Przygotowanie raportu 9 |  | 2h | 2012-06-01 09:00 | 2012-06-01 11:00 |  | 297.75d |  | start no earlier than 2012-06-01 09:00 |  |
| 58 | Budowa i zmiana lokalizacji-**.10 | Przygotowanie raportu 10 |  | 2h | 2012-06-08 09:00 | 2012-06-08 11:00 |  | 293.75d |  | start no earlier than 2012-06-08 09:00 |  |
| 59 | Budowa i zmiana lokalizacji-**.11 | Przygotowanie raportu 11 |  | 2h | 2012-06-15 09:00 | 2012-06-15 11:00 |  | 288.75d |  | start no earlier than 2012-06-15 09:00 |  |
| 60 | Budowa i zmiana lokalizacji-**.12 | Przygotowanie raportu 12 |  | 2h | 2012-06-22 09:00 | 2012-06-22 11:00 |  | 283.75d |  | start no earlier than 2012-06-22 09:00 |  |
| 61 | Budowa i zmiana lokalizacji-**.13 | Przygotowanie raportu 13 |  | 2h | 2012-06-29 09:00 | 2012-06-29 11:00 |  | 278.75d |  | start no earlier than 2012-06-29 09:00 |  |
| 62 | Budowa i zmiana lokalizacji-**.14 | Przygotowanie raportu 14 |  | 2h | 2012-07-06 09:00 | 2012-07-06 11:00 |  | 273.75d |  | start no earlier than 2012-07-06 09:00 |  |
| 63 | Budowa i zmiana lokalizacji-**.15 | Przygotowanie raportu 15 |  | 2h | 2012-07-13 09:00 | 2012-07-13 11:00 |  | 268.75d |  | start no earlier than 2012-07-13 09:00 |  |
| 64 | Budowa i zmiana lokalizacji-**.16 | Przygotowanie raportu 16 |  | 2h | 2012-07-20 09:00 | 2012-07-20 11:00 |  | 263.75d |  | start no earlier than 2012-07-20 09:00 |  |
| 65 | Budowa i zmiana lokalizacji-**.17 | Przygotowanie raportu 17 |  | 2h | 2012-07-27 09:00 | 2012-07-27 11:00 |  | 258.75d |  | start no earlier than 2012-07-27 09:00 |  |
| 66 | Budowa i zmiana lokalizacji-**.18 | Przygotowanie raportu 18 |  | 2h | 2012-08-03 09:00 | 2012-08-03 11:00 |  | 253.75d |  | start no earlier than 2012-08-03 09:00 |  |
| 67 | Budowa i zmiana lokalizacji-**.19 | Przygotowanie raportu 19 |  | 2h | 2012-08-10 09:00 | 2012-08-10 11:00 |  | 248.75d |  | start no earlier than 2012-08-10 09:00 |  |
| 68 | Budowa i zmiana lokalizacji-**.20 | Przygotowanie raportu 20 |  | 2h | 2012-08-17 09:00 | 2012-08-17 11:00 |  | 244.75d |  | start no earlier than 2012-08-17 09:00 |  |
| 69 | Budowa i zmiana lokalizacji-**.21 | Przygotowanie raportu 21 |  | 2h | 2012-08-24 09:00 | 2012-08-24 11:00 |  | 239.75d |  | start no earlier than 2012-08-24 09:00 |  |
| 70 | Budowa i zmiana lokalizacji-**.22 | Przygotowanie raportu 22 |  | 2h | 2012-08-31 09:00 | 2012-08-31 11:00 |  | 234.75d |  | start no earlier than 2012-08-31 09:00 |  |
| 71 | Budowa i zmiana lokalizacji-**.23 | Przygotowanie raportu 23 |  | 2h | 2012-09-07 09:00 | 2012-09-07 11:00 |  | 229.75d |  | start no earlier than 2012-09-07 09:00 |  |
| 72 | Budowa i zmiana lokalizacji-**.24 | Przygotowanie raportu 24 |  | 2h | 2012-09-14 09:00 | 2012-09-14 11:00 |  | 224.75d |  | start no earlier than 2012-09-14 09:00 |  |
| 73 | Budowa i zmiana lokalizacji-**.25 | Przygotowanie raportu 25 |  | 2h | 2012-09-21 09:00 | 2012-09-21 11:00 |  | 219.75d |  | start no earlier than 2012-09-21 09:00 |  |
| 74 | Budowa i zmiana lokalizacji-**.26 | Przygotowanie raportu 26 |  | 2h | 2012-09-28 09:00 | 2012-09-28 11:00 |  | 214.75d |  | start no earlier than 2012-09-28 09:00 |  |
| 75 | Budowa i zmiana lokalizacji-**.27 | Przygotowanie raportu 27 |  | 2h | 2012-10-05 09:00 | 2012-10-05 11:00 |  | 209.75d |  | start no earlier than 2012-10-05 09:00 |  |
| 76 | Budowa i zmiana lokalizacji-**.28 | Przygotowanie raportu 28 |  | 2h | 2012-10-12 09:00 | 2012-10-12 11:00 |  | 204.75d |  | start no earlier than 2012-10-12 09:00 |  |
| 77 | Budowa i zmiana lokalizacji-**.29 | Przygotowanie raportu 29 |  | 2h | 2012-10-19 09:00 | 2012-10-19 11:00 |  | 199.75d |  | start no earlier than 2012-10-19 09:00 |  |
| 78 | Budowa i zmiana lokalizacji-**.30 | Przygotowanie raportu 30 |  | 2h | 2012-10-26 09:00 | 2012-10-26 11:00 |  | 194.75d |  | start no earlier than 2012-10-26 09:00 |  |
| 79 | Budowa i zmiana lokalizacji-**.31 | Przygotowanie raportu 31 |  | 2h | 2012-11-02 09:00 | 2012-11-02 11:00 |  | 190.75d |  | start no earlier than 2012-11-02 09:00 |  |
| 80 | Budowa i zmiana lokalizacji-**.32 | Przygotowanie raportu 32 |  | 2h | 2012-11-09 09:00 | 2012-11-09 11:00 |  | 185.75d |  | start no earlier than 2012-11-09 09:00 |  |
| 81 | Budowa i zmiana lokalizacji-**.33 | Przygotowanie raportu 33 |  | 2h | 2012-11-16 09:00 | 2012-11-16 11:00 |  | 180.75d |  | start no earlier than 2012-11-16 09:00 |  |
| 82 | Budowa i zmiana lokalizacji-**.34 | Przygotowanie raportu 34 |  | 2h | 2012-11-23 09:00 | 2012-11-23 11:00 |  | 175.75d |  | start no earlier than 2012-11-23 09:00 |  |
| 83 | Budowa i zmiana lokalizacji-**.35 | Przygotowanie raportu 35 |  | 2h | 2012-11-30 09:00 | 2012-11-30 11:00 |  | 170.75d |  | start no earlier than 2012-11-30 09:00 |  |
| 84 | Budowa i zmiana lokalizacji-**.36 | Przygotowanie raportu 36 |  | 2h | 2012-12-07 09:00 | 2012-12-07 11:00 |  | 165.75d |  | start no earlier than 2012-12-07 09:00 |  |
| 85 | Budowa i zmiana lokalizacji-**.37 | Przygotowanie raportu 37 |  | 2h | 2012-12-14 09:00 | 2012-12-14 11:00 |  | 160.75d |  | start no earlier than 2012-12-14 09:00 |  |
| 86 | Budowa i zmiana lokalizacji-**.38 | Przygotowanie raportu 38 |  | 2h | 2012-12-21 09:00 | 2012-12-21 11:00 |  | 155.75d |  | start no earlier than 2012-12-21 09:00 |  |
| 87 | Budowa i zmiana lokalizacji-**.39 | Przygotowanie raportu 39 |  | 2h | 2012-12-28 09:00 | 2012-12-28 11:00 |  | 152.75d |  | start no earlier than 2012-12-28 09:00 |  |
| 88 | Budowa i zmiana lokalizacji-**.40 | Przygotowanie raportu 40 |  | 2h | 2013-01-04 09:00 | 2013-01-04 11:00 |  | 148.75d |  | start no earlier than 2013-01-04 09:00 |  |
| 89 | Budowa i zmiana lokalizacji-**.41 | Przygotowanie raportu 41 |  | 2h | 2013-01-11 09:00 | 2013-01-11 11:00 |  | 143.75d |  | start no earlier than 2013-01-11 09:00 |  |
| 90 | Budowa i zmiana lokalizacji-**.42 | Przygotowanie raportu 42 |  | 2h | 2013-01-18 09:00 | 2013-01-18 11:00 |  | 138.75d |  | start no earlier than 2013-01-18 09:00 |  |
| 91 | Budowa i zmiana lokalizacji-**.43 | Przygotowanie raportu 43 |  | 2h | 2013-01-25 09:00 | 2013-01-25 11:00 |  | 133.75d |  | start no earlier than 2013-01-25 09:00 |  |
| 92 | Budowa i zmiana lokalizacji-**.44 | Przygotowanie raportu 44 |  | 2h | 2013-02-01 09:00 | 2013-02-01 11:00 |  | 128.75d |  | start no earlier than 2013-02-01 09:00 |  |
| 93 | Budowa i zmiana lokalizacji-**.45 | Przygotowanie raportu 45 |  | 2h | 2013-02-08 09:00 | 2013-02-08 11:00 |  | 123.75d |  | start no earlier than 2013-02-08 09:00 |  |
| 94 | Budowa i zmiana lokalizacji-**.46 | Przygotowanie raportu 46 |  | 2h | 2013-02-15 09:00 | 2013-02-15 11:00 |  | 118.75d |  | start no earlier than 2013-02-15 09:00 |  |

| ID | WBS | Task | Type | Duration | Start | Finish | Predecessors | Total slack | Constraint | Deadline |
| --- | --- | --- | --- | --- | --- | --- | --- | --- | --- | --- |
| 95 | Budowa i zmiana lokalizacji-**.47 | Przygotowanie raportu 47 |  | 2h | 2013-02-22 09:00 | 2013-02-22 11:00 |  | 113.75d | start no earlier than 2013-02-22 09:00 |  |
| 96 | Budowa i zmiana lokalizacji-**.48 | Przygotowanie raportu 48 |  | 2h | 2013-03-01 09:00 | 2013-03-01 11:00 |  | 108.75d | start no earlier than 2013-03-01 09:00 |  |
| 97 | Budowa i zmiana lokalizacji-**.49 | Przygotowanie raportu 49 |  | 2h | 2013-03-08 09:00 | 2013-03-08 11:00 |  | 103.75d | start no earlier than 2013-03-08 09:00 |  |
| 98 | Budowa i zmiana lokalizacji-**.50 | Przygotowanie raportu 50 |  | 2h | 2013-03-15 09:00 | 2013-03-15 11:00 |  | 98.75d | start no earlier than 2013-03-15 09:00 |  |
| 99 | Budowa i zmiana lokalizacji-**.51 | Przygotowanie raportu 51 |  | 2h | 2013-03-22 09:00 | 2013-03-22 11:00 |  | 93.75d | start no earlier than 2013-03-22 09:00 |  |
| 100 | Budowa i zmiana lokalizacji-**.52 | Przygotowanie raportu 52 |  | 2h | 2013-03-29 09:00 | 2013-03-29 11:00 |  | 88.75d | start no earlier than 2013-03-29 09:00 |  |
| 101 | Budowa i zmiana lokalizacji-**.53 | Przygotowanie raportu 53 |  | 2h | 2013-04-05 09:00 | 2013-04-05 11:00 |  | 83.75d | start no earlier than 2013-04-05 09:00 |  |
| 102 | Budowa i zmiana lokalizacji-**.54 | Przygotowanie raportu 54 |  | 2h | 2013-04-12 09:00 | 2013-04-12 11:00 |  | 78.75d | start no earlier than 2013-04-12 09:00 |  |
| 103 | Budowa i zmiana lokalizacji-**.55 | Przygotowanie raportu 55 |  | 2h | 2013-04-19 09:00 | 2013-04-19 11:00 |  | 73.75d | start no earlier than 2013-04-19 09:00 |  |
| 104 | Budowa i zmiana lokalizacji-**.56 | Przygotowanie raportu 56 |  | 2h | 2013-04-26 09:00 | 2013-04-26 11:00 |  | 68.75d | start no earlier than 2013-04-26 09:00 |  |
| 105 | Budowa i zmiana lokalizacji-**.57 | Przygotowanie raportu 57 |  | 2h | 2013-05-06 08:00 | 2013-05-06 10:00 |  | 64.88d | start no earlier than 2013-05-03 09:00 |  |
| 106 | Budowa i zmiana lokalizacji-**.58 | Przygotowanie raportu 58 |  | 2h | 2013-05-10 09:00 | 2013-05-10 11:00 |  | 60.75d | start no earlier than 2013-05-10 09:00 |  |
| 107 | Budowa i zmiana lokalizacji-**.59 | Przygotowanie raportu 59 |  | 2h | 2013-05-17 09:00 | 2013-05-17 11:00 |  | 55.75d | start no earlier than 2013-05-17 09:00 |  |
| 108 | Budowa i zmiana lokalizacji-**.60 | Przygotowanie raportu 60 |  | 2h | 2013-05-24 09:00 | 2013-05-24 11:00 |  | 50.75d | start no earlier than 2013-05-24 09:00 |  |
| 109 | Budowa i zmiana lokalizacji-**.61 | Przygotowanie raportu 61 |  | 2h | 2013-05-31 09:00 | 2013-05-31 11:00 |  | 45.75d | start no earlier than 2013-05-31 09:00 |  |
| 110 | Budowa i zmiana lokalizacji-** | Wprowadzanie poprawek | inactive, manual | 1d? | 2013-08-06 08:00 | 2013-08-06 16:00 |  |  |  |  |
| 111 | Budowa i zmiana lokalizacji-** | Koniec | milestone | 0d | 2013-08-05 09:00 | 2013-08-05 09:00 | 47 | 0d | finish no later than 2013-09-30 16:00 | 2013-09-30 16:00 |
