# Budowa i zmiana lokalizacji

Schedule from MS Project, 2012-04-02 to 2013-08-07, costs in zł.
Przeprowadzka firmy do nowo wybudowanej siedziby
Firma sp z.o.

## Calendars

- Kalendarz firmowy Firma sp. z o.o.: Mon-Fri 08:00-16:00; Sat-Sun off. Exceptions (off unless hours are given): 2012-01-01 to 2021-01-01 (Nowy Rok, recurring), 2012-04-09 (Poniedziałek Wielkanocny), 2012-05-01 to 2021-05-01 (Święto Pracy, recurring), 2012-05-03 to 2021-05-03 (Święto Konstytucji 3 maja, recurring), 2012-06-07 (Boże Ciało), 2012-08-15 to 2021-08-15 (Święto Wojska Polskiego, recurring), 2012-11-01 to 2021-11-01 (Wszystkich Świętych, recurring), 2012-11-11 to 2021-11-11 (Święto Niepodległości, recurring), 2012-12-25 to 2021-12-25 (Boże Narodzienie (pierwszy dzień), recurring), 2012-12-26 (Boże Narodzenie (drugi dzień)).

## Resources

| Resource | Group | Unit | Rate |
| --- | --- | --- | --- |
| Katarzyna Kalka | Pracownik administracyjny |  | 33 |
| Sebastian Wilczewski | Kierownik projektu |  | 80 |
| Andrzej Sójka | Dział radców prawnych |  | 110 |
| Piotr Krauze | Zarząd |  | 130 |
| Władysław Lis | Pracownik administracyjny |  | 30 |
| ArchiTekt | Firma zewnętrzna |  |  |
| Budmor | Firma zewnętrzna |  |  |
| DekorArt | Firma zewnętrzna |  |  |
| Super AGD | Firma zewnętrzna |  |  |
| Heros | Firma zewnętrzna |  |  |
| Maciej Klos | Dział informatyki |  | 45 |
| Informatyk | Dział informatyki |  | 35 |
| Pracownik pomocniczy | Pracownik administracyjny |  | 28 |
| Usługi obce | Budżet |  |  |
| Zaangażowanie własne | Budżet |  |  |
| Kawa | Materiały pomocnicze | kubek | 2 |
| Bułki | Materiały pomocnicze | szt. | 3.5 |
| Materiały pomocnicze | Budżet |  |  |

## Schedule

| ID | WBS | Task | Type | Duration | Start | Finish | Predecessors | Baseline start | Baseline finish | Baseline duration | Total slack | Free slack | Constraint | Resources | Work | Cost | Baseline cost |
| --- | --- | --- | --- | --- | --- | --- | --- | --- | --- | --- | --- | --- | --- | --- | --- | --- | --- |
| 1 | Budowa i zmiana lokalizacji-** | Start | milestone | 0d | 2012-04-02 09:00 | 2012-04-02 09:00 |  | 2012-04-02 09:00 | 2012-04-02 09:00 | 0d | 0d |  |  |  |  |  |  |
| 2 | Budowa i zmiana lokalizacji-** | **Analiza potrzeb** |  | 9d | 2012-04-02 09:00 | 2012-04-16 09:00 |  | 2012-04-02 09:00 | 2012-04-16 09:00 | 9d | 0d |  |  |  | 16h | 604 | 604 |
| 3 | Budowa i zmiana lokalizacji-**.01 | Opracowanie i rozesłanie ankiet |  | 1d | 2012-04-02 09:00 | 2012-04-03 09:00 | 1 | 2012-04-02 09:00 | 2012-04-03 09:00 | 1d | 0d |  |  | Katarzyna Kalka | 8h | 314 | 314 |
| 4 | Budowa i zmiana lokalizacji-**.02 | Opracowanie zestawienia z wyników ankiet |  | 1d | 2012-04-13 09:00 | 2012-04-16 09:00 | 3FS+7d | 2012-04-13 09:00 | 2012-04-16 09:00 | 1d | 0d |  |  | Władysław Lis | 8h | 290 | 290 |
| 5 | Budowa i zmiana lokalizacji-**.03 | Analiza potrzeb zakończona | milestone | 0d | 2012-04-16 09:00 | 2012-04-16 09:00 | 4 | 2012-04-16 09:00 | 2012-04-16 09:00 | 0d | 0d |  |  |  |  |  |  |
| 6 | Budowa i zmiana lokalizacji-** | **Wybór wykonawców** |  | 29.5d? | 2012-04-16 09:00 | 2012-05-29 13:00 |  | 2012-04-16 09:00 | 2012-05-29 13:00 | 29.5d? | 0d |  |  |  | 212h | 11,312 | 11,312 |
| 7 | Budowa i zmiana lokalizacji-**.01 | Przygotowanie treści zapytania ofertowego i rozesłanie zapytań do potencjalnych wykonawców |  | 15d? | 2012-04-16 09:00 | 2012-05-09 09:00 | 5 | 2012-04-16 09:00 | 2012-05-09 09:00 | 15d? | 0d |  |  | Katarzyna Kalka; Piotr Krauze [20%] | 144h | 7,280 | 7,280 |
| 8 | Budowa i zmiana lokalizacji-**.02 | Udzielenie odpowiedzi na pytania wykonawców |  | 2d | 2012-05-16 09:00 | 2012-05-18 09:00 | 7FS+5d | 2012-05-16 09:00 | 2012-05-18 09:00 | 2d | 7.75d | 0d |  | Władysław Lis; Katarzyna Kalka; Andrzej Sójka [20%]; Sebastian Wilczewski [20%]; Piotr Krauze [10%] | 40h | 1,924 | 1,924 |
| 9 | Budowa i zmiana lokalizacji-**.03 | Zakończenie składania ofert | milestone | 0d | 2012-05-23 09:00 | 2012-05-23 09:00 | 8FS+3d | 2012-05-23 09:00 | 2012-05-23 09:00 | 0d | 7.75d | 0d |  |  |  |  |  |
| 10 | Budowa i zmiana lokalizacji-**.04 | Ocena ofert i wyłonienie wykonawcy |  | 2d | 2012-05-23 09:00 | 2012-05-25 09:00 | 9 | 2012-05-23 09:00 | 2012-05-25 09:00 | 2d | 7.75d | 0d |  | Katarzyna Kalka | 16h | 528 | 528 |
| 11 | Budowa i zmiana lokalizacji-**.05 | Podpisanie umowy |  | 0.5d | 2012-05-29 09:00 | 2012-05-29 13:00 | 10FS+2d | 2012-05-29 09:00 | 2012-05-29 13:00 | 0.5d | 7.75d | 0d | finish no later than 2012-06-30 16:00 | Piotr Krauze; Sebastian Wilczewski; Andrzej Sójka | 12h | 1,580 | 1,580 |
| 12 | Budowa i zmiana lokalizacji-**.06 | Wybór wykonawców zakończony | milestone | 0d | 2012-05-29 13:00 | 2012-05-29 13:00 | 11 | 2012-05-29 13:00 | 2012-05-29 13:00 | 0d | 7.75d |  |  |  |  |  |  |
| 13 | Budowa i zmiana lokalizacji-** | **Budowa nowej siedziby** |  | 322.25d? | 2012-04-16 09:00 | 2013-07-24 11:00 |  | 2012-04-16 09:00 | 2013-07-24 11:00 | 322.25d? | 0d |  |  |  | 254h | 2,574,572 | 2,574,572 |
| 14 | Budowa i zmiana lokalizacji-**.01 | Opracowanie i złożenie wniosków o wydanie zezwoleń |  | 7d? | 2012-04-16 09:00 | 2012-04-25 09:00 | 7SS, 12 | 2012-04-16 09:00 | 2012-04-25 09:00 | 7d? | 0d |  |  | Władysław Lis; Sebastian Wilczewski [20%]; Piotr Krauze [10%] | 72.8h | 3,304 | 3,304 |
| 15 | Budowa i zmiana lokalizacji-**.02 | Odbiór zezwoleń |  | 2h | 2012-06-11 09:00 | 2012-06-11 11:00 | 14FS+30d | 2012-06-11 09:00 | 2012-06-11 11:00 | 2h | 0d |  |  | Władysław Lis | 2h | 160 | 160 |
| 16 | Budowa i zmiana lokalizacji-**.03 | **Budowa** |  | 204d | 2012-06-11 11:00 | 2013-03-29 11:00 |  | 2012-06-11 11:00 | 2013-03-29 11:00 | 204d | 0d |  |  |  |  | 1,850,000 | 1,850,000 |
| 17 | Budowa i zmiana lokalizacji-**.03.01 | Etap I - Prace ziemne |  | 1mo | 2012-06-11 11:00 | 2012-07-09 11:00 | 15, 12 | 2012-06-11 11:00 | 2012-07-09 11:00 | 1mo | 0d |  | finish no later than 2012-11-01 16:00 | Budmor [0.1%] |  | 250,000 | 250,000 |
| 18 | Budowa i zmiana lokalizacji-**.03.02 | Etap II - Konstrukcja budynku i elewacje |  | 4mo | 2012-07-09 11:00 | 2012-10-30 11:00 | 17 | 2012-07-09 11:00 | 2012-10-30 11:00 | 4mo | 0d |  |  | Budmor [0.1%] |  | 700,000 | 700,000 |
| 19 | Budowa i zmiana lokalizacji-**.03.03 | Etap III - Prace wykończeniowe i inne |  | 6mo | 2012-10-08 11:00 | 2013-03-29 11:00 | 18FS-2% | 2012-10-08 11:00 | 2013-03-29 11:00 | 6mo | 0d |  |  | Budmor [0.1%] |  | 900,000 | 900,000 |
| 20 | Budowa i zmiana lokalizacji-**.04 | **Aranżacja i wyposażanie** |  | 283d | 2012-06-11 11:00 | 2013-07-22 11:00 |  | 2012-06-11 11:00 | 2013-07-22 11:00 | 283d | 0d |  |  |  | 128h | 718,204 | 718,204 |
| 21 | Budowa i zmiana lokalizacji-**.04.01 | Wykonanie projektu |  | 10d | 2012-06-11 11:00 | 2012-06-25 11:00 | 15 | 2012-06-11 11:00 | 2012-06-25 11:00 | 10d | 187.5d | 0d |  | DekorArt [0.1%] |  | 20,000 | 20,000 |
| 22 | Budowa i zmiana lokalizacji-**.04.02 | Rozesłanie zapytań do potencjalnych wykonawców |  | 4h | 2012-06-25 11:00 | 2012-06-25 15:00 | 21 | 2012-06-25 11:00 | 2012-06-25 15:00 | 4h | 187.5d | 0d |  | Katarzyna Kalka; Władysław Lis | 8h | 252 | 252 |
| 23 | Budowa i zmiana lokalizacji-**.04.03 | Udzielanie odpowiedzi na pytania potencjalnych wykonawców |  | 2d | 2012-06-25 15:00 | 2012-06-27 15:00 | 22 | 2012-06-25 15:00 | 2012-06-27 15:00 | 2d | 187.5d | 0d |  | Władysław Lis; Katarzyna Kalka; Andrzej Sójka [20%]; Sebastian Wilczewski [20%]; Piotr Krauze [10%] | 40h | 1,824 | 1,824 |
| 24 | Budowa i zmiana lokalizacji-**.04.04 | Wybór wykonawcy i podpisanie umowy |  | 2d | 2012-06-29 15:00 | 2012-07-03 15:00 | 23FS+2d | 2012-06-29 15:00 | 2012-07-03 15:00 | 2d | 187.5d |  |  | Piotr Krauze; Sebastian Wilczewski; Andrzej Sójka | 48h | 5,120 | 5,120 |

Notes:
- 3: W ankiecie należy uwzględnić takie zagadnienia jak: / ·Powierzchnia biurowa / ·Klimatyzacja / ·Dostępność miejsc parkingowych / ·Nasłonecznienie

| ID | WBS | Task | Type | Duration | Start | Finish | Predecessors | Baseline start | Baseline finish | Baseline duration | Total slack | Free slack | Constraint | Deadline | Resources | Work | Cost | Baseline cost |
| --- | --- | --- | --- | --- | --- | --- | --- | --- | --- | --- | --- | --- | --- | --- | --- | --- | --- | --- |
| 25 | Budowa i zmiana lokalizacji-**.04.05 | **Prace aranżacyjno wykończeniowe** |  | 79d | 2013-03-29 11:00 | 2013-07-22 11:00 |  | 2013-03-29 11:00 | 2013-07-22 11:00 | 79d | 0d |  |  |  |  | 32h | 691,008 | 691,008 |
| 26 | Budowa i zmiana lokalizacji-**.04.05.AA | Aranżacje |  | 3mo | 2013-03-29 11:00 | 2013-06-25 11:00 | 24, 19 | 2013-03-29 11:00 | 2013-06-25 11:00 | 3mo | 0d |  |  |  | ArchiTekt [0.1%] |  | 600,000 | 600,000 |
| 27 | Budowa i zmiana lokalizacji-**.04.05.AB | Zakup sprzętu |  | 2d | 2013-06-21 11:00 | 2013-06-25 11:00 | 26FF | 2013-06-21 11:00 | 2013-06-25 11:00 | 2d | 0d |  |  |  | Katarzyna Kalka; Władysław Lis | 32h | 1,008 | 1,008 |
| 28 | Budowa i zmiana lokalizacji-**.04.05.AC | Dostawa i montaż |  | 5d | 2013-07-15 11:00 | 2013-07-22 11:00 | 27FS+14d | 2013-07-15 11:00 | 2013-07-22 11:00 | 5d | 0d |  |  |  | Super AGD [0.1%] |  | 90,000 | 90,000 |
| 29 | Budowa i zmiana lokalizacji-**.04.05.AD | Prace aranżacyjno wykończeniowe zakończone | milestone | 0d | 2013-07-22 11:00 | 2013-07-22 11:00 | 28 | 2013-07-22 11:00 | 2013-07-22 11:00 | 0d | 0d |  |  |  |  |  |  |  |
| 30 | Budowa i zmiana lokalizacji-**.05 | Odbiór budynku |  | 2d | 2013-07-22 11:00 | 2013-07-24 11:00 | 29 | 2013-07-22 11:00 | 2013-07-24 11:00 | 2d | 0d |  |  |  | Sebastian Wilczewski; Piotr Krauze [20%]; Władysław Lis; Katarzyna Kalka | 51.2h | 2,904 | 2,904 |
| 31 | Budowa i zmiana lokalizacji-**.06 | Budowa zakończona | milestone | 0d | 2013-07-24 11:00 | 2013-07-24 11:00 | 30 | 2013-07-24 11:00 | 2013-07-24 11:00 | 0d | 0d |  |  | 2013-07-31 16:00 |  |  |  |  |
| 32 | Budowa i zmiana lokalizacji-** | **Przygotowanie do przeprowadzki** |  | 5d | 2013-07-24 11:00 | 2013-07-31 11:00 |  | 2013-07-24 11:00 | 2013-07-31 11:00 | 5d | 0d |  |  |  |  | 55.2h | 2,736 | 2,736 |
| 33 | Budowa i zmiana lokalizacji-**.01 | Stworzenie planu przeprowadzki |  | 3d | 2013-07-24 11:00 | 2013-07-29 11:00 | 31 | 2013-07-24 11:00 | 2013-07-29 11:00 | 3d | 0d |  |  |  | Sebastian Wilczewski [50%]; Katarzyna Kalka | 36h | 1,952 | 1,952 |
| 34 | Budowa i zmiana lokalizacji-**.02 | Pozyskanie firmy przeprowadzkowej |  | 2d | 2013-07-29 11:00 | 2013-07-31 11:00 | 33FF | 2013-07-29 11:00 | 2013-07-31 11:00 | 2d | 0d |  |  |  | Katarzyna Kalka; Sebastian Wilczewski [20%] | 19.2h | 784 | 784 |
| 35 | Budowa i zmiana lokalizacji-**.03 | Przygotowanie do przeprowadzki zakończone | milestone | 0d | 2013-07-31 11:00 | 2013-07-31 11:00 | 34 | 2013-07-31 11:00 | 2013-07-31 11:00 | 0d | 0d |  |  |  |  |  |  |  |
| 36 | Budowa i zmiana lokalizacji-** | **Przeprowadzka** |  | 4.75d | 2013-07-31 11:00 | 2013-08-07 09:00 |  | 2013-07-31 11:00 | 2013-08-07 09:00 | 4.75d | 0d |  |  |  | Kawa [200 kubek]; Bułki [120 szt.] | 208h | 8,232 | 8,232 |
| 37 | Budowa i zmiana lokalizacji-**.01 | **Prace w starej siedzibie** |  | 2.5d | 2013-07-31 11:00 | 2013-08-02 15:00 |  | 2013-07-31 11:00 | 2013-08-02 15:00 | 2.5d | 0d |  |  |  |  | 88h | 3,160 | 3,160 |
| 38 | Budowa i zmiana lokalizacji-**.01.01 | Pakowanie i demontaż |  | 1d | 2013-07-31 11:00 | 2013-08-01 11:00 | 35 | 2013-07-31 11:00 | 2013-08-01 11:00 | 1d | 0d |  |  |  | Pracownik pomocniczy [400%] | 32h | 1,096 | 1,096 |
| 39 | Budowa i zmiana lokalizacji-**.01.02 | Załadunek i transport |  | 4h | 2013-08-01 11:00 | 2013-08-01 15:00 | 38 | 2013-08-01 11:00 | 2013-08-01 15:00 | 4h | 0d |  |  |  | Pracownik pomocniczy [400%] | 16h | 548 | 548 |
| 40 | Budowa i zmiana lokalizacji-**.01.03 | Demontaż infrastruktury teleinformatyczne |  | 6h | 2013-08-01 15:00 | 2013-08-02 13:00 | 39 | 2013-08-01 15:00 | 2013-08-02 13:00 | 6h | 0.25d | 0d |  |  | Informatyk [400%]; Maciej Klos | 30h | 1,137 | 1,137 |
| 41 | Budowa i zmiana lokalizacji-**.01.04 | Transport infrastruktury teleinformatycznej |  | 2h | 2013-08-02 13:00 | 2013-08-02 15:00 | 40 | 2013-08-02 13:00 | 2013-08-02 15:00 | 2h | 0.25d | 0d |  |  | Informatyk [400%]; Maciej Klos | 10h | 379 | 379 |
| 42 | Budowa i zmiana lokalizacji-**.01.05 | Prace w starej siedzibie zakończone | milestone | 0d | 2013-08-02 15:00 | 2013-08-02 15:00 | 41 | 2013-08-02 15:00 | 2013-08-02 15:00 | 0d | 2.25d |  |  |  |  |  |  |  |
| 43 | Budowa i zmiana lokalizacji-**.02 | **Prace w nowej siedzibie** |  | 3.25d | 2013-08-01 15:00 | 2013-08-07 09:00 |  | 2013-08-01 15:00 | 2013-08-07 09:00 | 3.25d | 0d |  |  |  |  | 120h | 4,252 | 4,252 |
| 44 | Budowa i zmiana lokalizacji-**.02.01 | Rozładunek |  | 2h | 2013-08-01 15:00 | 2013-08-02 09:00 | 39, 42 | 2013-08-01 15:00 | 2013-08-02 09:00 | 2h | 0d |  |  |  | Pracownik pomocniczy [400%] | 8h | 224 | 224 |
| 45 | Budowa i zmiana lokalizacji-**.02.02 | Rozpakowanie i ustawianie wyposażanie |  | 1d | 2013-08-02 09:00 | 2013-08-05 09:00 | 44 | 2013-08-02 09:00 | 2013-08-05 09:00 | 1d | 0d |  |  |  | Pracownik pomocniczy [400%] | 32h | 996 | 996 |
| 46 | Budowa i zmiana lokalizacji-**.02.03 | Montaż i uruchomienie infrastruktury teleinformatycznej |  | 16h | 2013-08-05 09:00 | 2013-08-07 09:00 | 45, 41 | 2013-08-05 09:00 | 2013-08-07 09:00 | 16h | 0d |  |  |  | Informatyk [400%]; Maciej Klos | 80h | 3,032 | 3,032 |
| 47 | Budowa i zmiana lokalizacji-**.02.04 | Prace w nowej siedzibie zakończone | milestone | 0d | 2013-08-07 09:00 | 2013-08-07 09:00 | 46, 42 | 2013-08-07 09:00 | 2013-08-07 09:00 | 0d | 0d |  |  |  |  |  |  |  |
| 48 | Budowa i zmiana lokalizacji-** | **Przygotowanie raportu** |  | 289.25d | 2012-04-06 09:00 | 2013-05-31 11:00 |  | 2012-04-06 09:00 | 2013-05-31 11:00 | 289.25d | 47.75d |  |  |  |  | 122h | 9,760 | 9,760 |
| 49 | Budowa i zmiana lokalizacji-**.01 | Przygotowanie raportu 1 |  | 2h | 2012-04-06 09:00 | 2012-04-06 11:00 |  | 2012-04-06 09:00 | 2012-04-06 11:00 | 2h | 334.75d |  | start no earlier than 2012-04-06 09:00 |  | Sebastian Wilczewski | 2h | 160 | 160 |
| 50 | Budowa i zmiana lokalizacji-**.02 | Przygotowanie raportu 2 |  | 2h | 2012-04-13 09:00 | 2012-04-13 11:00 |  | 2012-04-13 09:00 | 2012-04-13 11:00 | 2h | 330.75d |  | start no earlier than 2012-04-13 09:00 |  | Sebastian Wilczewski | 2h | 160 | 160 |
| 51 | Budowa i zmiana lokalizacji-**.03 | Przygotowanie raportu 3 |  | 2h | 2012-04-20 09:00 | 2012-04-20 11:00 |  | 2012-04-20 09:00 | 2012-04-20 11:00 | 2h | 325.75d |  | start no earlier than 2012-04-20 09:00 |  | Sebastian Wilczewski | 2h | 160 | 160 |
| 52 | Budowa i zmiana lokalizacji-**.04 | Przygotowanie raportu 4 |  | 2h | 2012-04-27 09:00 | 2012-04-27 11:00 |  | 2012-04-27 09:00 | 2012-04-27 11:00 | 2h | 320.75d |  | start no earlier than 2012-04-27 09:00 |  | Sebastian Wilczewski | 2h | 160 | 160 |
| 53 | Budowa i zmiana lokalizacji-**.05 | Przygotowanie raportu 5 |  | 2h | 2012-05-04 09:00 | 2012-05-04 11:00 |  | 2012-05-04 09:00 | 2012-05-04 11:00 | 2h | 317.75d |  | start no earlier than 2012-05-04 09:00 |  | Sebastian Wilczewski | 2h | 160 | 160 |
| 54 | Budowa i zmiana lokalizacji-**.06 | Przygotowanie raportu 6 |  | 2h | 2012-05-11 09:00 | 2012-05-11 11:00 |  | 2012-05-11 09:00 | 2012-05-11 11:00 | 2h | 312.75d |  | start no earlier than 2012-05-11 09:00 |  | Sebastian Wilczewski | 2h | 160 | 160 |
| 55 | Budowa i zmiana lokalizacji-**.07 | Przygotowanie raportu 7 |  | 2h | 2012-05-18 09:00 | 2012-05-18 11:00 |  | 2012-05-18 09:00 | 2012-05-18 11:00 | 2h | 307.75d |  | start no earlier than 2012-05-18 09:00 |  | Sebastian Wilczewski | 2h | 160 | 160 |
| 56 | Budowa i zmiana lokalizacji-**.08 | Przygotowanie raportu 8 |  | 2h | 2012-05-25 09:00 | 2012-05-25 11:00 |  | 2012-05-25 09:00 | 2012-05-25 11:00 | 2h | 302.75d |  | start no earlier than 2012-05-25 09:00 |  | Sebastian Wilczewski | 2h | 160 | 160 |
| 57 | Budowa i zmiana lokalizacji-**.09 | Przygotowanie raportu 9 |  | 2h | 2012-06-01 09:00 | 2012-06-01 11:00 |  | 2012-06-01 09:00 | 2012-06-01 11:00 | 2h | 297.75d |  | start no earlier than 2012-06-01 09:00 |  | Sebastian Wilczewski | 2h | 160 | 160 |
| 58 | Budowa i zmiana lokalizacji-**.10 | Przygotowanie raportu 10 |  | 2h | 2012-06-08 09:00 | 2012-06-08 11:00 |  | 2012-06-08 09:00 | 2012-06-08 11:00 | 2h | 293.75d |  | start no earlier than 2012-06-08 09:00 |  | Sebastian Wilczewski | 2h | 160 | 160 |
| 59 | Budowa i zmiana lokalizacji-**.11 | Przygotowanie raportu 11 |  | 2h | 2012-06-15 09:00 | 2012-06-15 11:00 |  | 2012-06-15 09:00 | 2012-06-15 11:00 | 2h | 288.75d |  | start no earlier than 2012-06-15 09:00 |  | Sebastian Wilczewski | 2h | 160 | 160 |
| 60 | Budowa i zmiana lokalizacji-**.12 | Przygotowanie raportu 12 |  | 2h | 2012-06-22 09:00 | 2012-06-22 11:00 |  | 2012-06-22 09:00 | 2012-06-22 11:00 | 2h | 283.75d |  | start no earlier than 2012-06-22 09:00 |  | Sebastian Wilczewski | 2h | 160 | 160 |
| 61 | Budowa i zmiana lokalizacji-**.13 | Przygotowanie raportu 13 |  | 2h | 2012-06-29 09:00 | 2012-06-29 11:00 |  | 2012-06-29 09:00 | 2012-06-29 11:00 | 2h | 278.75d |  | start no earlier than 2012-06-29 09:00 |  | Sebastian Wilczewski | 2h | 160 | 160 |
| 62 | Budowa i zmiana lokalizacji-**.14 | Przygotowanie raportu 14 |  | 2h | 2012-07-06 09:00 | 2012-07-06 11:00 |  | 2012-07-06 09:00 | 2012-07-06 11:00 | 2h | 273.75d |  | start no earlier than 2012-07-06 09:00 |  | Sebastian Wilczewski | 2h | 160 | 160 |
| 63 | Budowa i zmiana lokalizacji-**.15 | Przygotowanie raportu 15 |  | 2h | 2012-07-13 09:00 | 2012-07-13 11:00 |  | 2012-07-13 09:00 | 2012-07-13 11:00 | 2h | 268.75d |  | start no earlier than 2012-07-13 09:00 |  | Sebastian Wilczewski | 2h | 160 | 160 |
| 64 | Budowa i zmiana lokalizacji-**.16 | Przygotowanie raportu 16 |  | 2h | 2012-07-20 09:00 | 2012-07-20 11:00 |  | 2012-07-20 09:00 | 2012-07-20 11:00 | 2h | 263.75d |  | start no earlier than 2012-07-20 09:00 |  | Sebastian Wilczewski | 2h | 160 | 160 |
| 65 | Budowa i zmiana lokalizacji-**.17 | Przygotowanie raportu 17 |  | 2h | 2012-07-27 09:00 | 2012-07-27 11:00 |  | 2012-07-27 09:00 | 2012-07-27 11:00 | 2h | 258.75d |  | start no earlier than 2012-07-27 09:00 |  | Sebastian Wilczewski | 2h | 160 | 160 |
| 66 | Budowa i zmiana lokalizacji-**.18 | Przygotowanie raportu 18 |  | 2h | 2012-08-03 09:00 | 2012-08-03 11:00 |  | 2012-08-03 09:00 | 2012-08-03 11:00 | 2h | 253.75d |  | start no earlier than 2012-08-03 09:00 |  | Sebastian Wilczewski | 2h | 160 | 160 |
| 67 | Budowa i zmiana lokalizacji-**.19 | Przygotowanie raportu 19 |  | 2h | 2012-08-10 09:00 | 2012-08-10 11:00 |  | 2012-08-10 09:00 | 2012-08-10 11:00 | 2h | 248.75d |  | start no earlier than 2012-08-10 09:00 |  | Sebastian Wilczewski | 2h | 160 | 160 |
| 68 | Budowa i zmiana lokalizacji-**.20 | Przygotowanie raportu 20 |  | 2h | 2012-08-17 09:00 | 2012-08-17 11:00 |  | 2012-08-17 09:00 | 2012-08-17 11:00 | 2h | 244.75d |  | start no earlier than 2012-08-17 09:00 |  | Sebastian Wilczewski | 2h | 160 | 160 |
| 69 | Budowa i zmiana lokalizacji-**.21 | Przygotowanie raportu 21 |  | 2h | 2012-08-24 09:00 | 2012-08-24 11:00 |  | 2012-08-24 09:00 | 2012-08-24 11:00 | 2h | 239.75d |  | start no earlier than 2012-08-24 09:00 |  | Sebastian Wilczewski | 2h | 160 | 160 |
| 70 | Budowa i zmiana lokalizacji-**.22 | Przygotowanie raportu 22 |  | 2h | 2012-08-31 09:00 | 2012-08-31 11:00 |  | 2012-08-31 09:00 | 2012-08-31 11:00 | 2h | 234.75d |  | start no earlier than 2012-08-31 09:00 |  | Sebastian Wilczewski | 2h | 160 | 160 |
| 71 | Budowa i zmiana lokalizacji-**.23 | Przygotowanie raportu 23 |  | 2h | 2012-09-07 09:00 | 2012-09-07 11:00 |  | 2012-09-07 09:00 | 2012-09-07 11:00 | 2h | 229.75d |  | start no earlier than 2012-09-07 09:00 |  | Sebastian Wilczewski | 2h | 160 | 160 |
| 72 | Budowa i zmiana lokalizacji-**.24 | Przygotowanie raportu 24 |  | 2h | 2012-09-14 09:00 | 2012-09-14 11:00 |  | 2012-09-14 09:00 | 2012-09-14 11:00 | 2h | 224.75d |  | start no earlier than 2012-09-14 09:00 |  | Sebastian Wilczewski | 2h | 160 | 160 |
| 73 | Budowa i zmiana lokalizacji-**.25 | Przygotowanie raportu 25 |  | 2h | 2012-09-21 09:00 | 2012-09-21 11:00 |  | 2012-09-21 09:00 | 2012-09-21 11:00 | 2h | 219.75d |  | start no earlier than 2012-09-21 09:00 |  | Sebastian Wilczewski | 2h | 160 | 160 |
| 74 | Budowa i zmiana lokalizacji-**.26 | Przygotowanie raportu 26 |  | 2h | 2012-09-28 09:00 | 2012-09-28 11:00 |  | 2012-09-28 09:00 | 2012-09-28 11:00 | 2h | 214.75d |  | start no earlier than 2012-09-28 09:00 |  | Sebastian Wilczewski | 2h | 160 | 160 |
| 75 | Budowa i zmiana lokalizacji-**.27 | Przygotowanie raportu 27 |  | 2h | 2012-10-05 09:00 | 2012-10-05 11:00 |  | 2012-10-05 09:00 | 2012-10-05 11:00 | 2h | 209.75d |  | start no earlier than 2012-10-05 09:00 |  | Sebastian Wilczewski | 2h | 160 | 160 |
| 76 | Budowa i zmiana lokalizacji-**.28 | Przygotowanie raportu 28 |  | 2h | 2012-10-12 09:00 | 2012-10-12 11:00 |  | 2012-10-12 09:00 | 2012-10-12 11:00 | 2h | 204.75d |  | start no earlier than 2012-10-12 09:00 |  | Sebastian Wilczewski | 2h | 160 | 160 |
| 77 | Budowa i zmiana lokalizacji-**.29 | Przygotowanie raportu 29 |  | 2h | 2012-10-19 09:00 | 2012-10-19 11:00 |  | 2012-10-19 09:00 | 2012-10-19 11:00 | 2h | 199.75d |  | start no earlier than 2012-10-19 09:00 |  | Sebastian Wilczewski | 2h | 160 | 160 |
| 78 | Budowa i zmiana lokalizacji-**.30 | Przygotowanie raportu 30 |  | 2h | 2012-10-26 09:00 | 2012-10-26 11:00 |  | 2012-10-26 09:00 | 2012-10-26 11:00 | 2h | 194.75d |  | start no earlier than 2012-10-26 09:00 |  | Sebastian Wilczewski | 2h | 160 | 160 |
| 79 | Budowa i zmiana lokalizacji-**.31 | Przygotowanie raportu 31 |  | 2h | 2012-11-02 09:00 | 2012-11-02 11:00 |  | 2012-11-02 09:00 | 2012-11-02 11:00 | 2h | 190.75d |  | start no earlier than 2012-11-02 09:00 |  | Sebastian Wilczewski | 2h | 160 | 160 |
| 80 | Budowa i zmiana lokalizacji-**.32 | Przygotowanie raportu 32 |  | 2h | 2012-11-09 09:00 | 2012-11-09 11:00 |  | 2012-11-09 09:00 | 2012-11-09 11:00 | 2h | 185.75d |  | start no earlier than 2012-11-09 09:00 |  | Sebastian Wilczewski | 2h | 160 | 160 |
| 81 | Budowa i zmiana lokalizacji-**.33 | Przygotowanie raportu 33 |  | 2h | 2012-11-16 09:00 | 2012-11-16 11:00 |  | 2012-11-16 09:00 | 2012-11-16 11:00 | 2h | 180.75d |  | start no earlier than 2012-11-16 09:00 |  | Sebastian Wilczewski | 2h | 160 | 160 |
| 82 | Budowa i zmiana lokalizacji-**.34 | Przygotowanie raportu 34 |  | 2h | 2012-11-23 09:00 | 2012-11-23 11:00 |  | 2012-11-23 09:00 | 2012-11-23 11:00 | 2h | 175.75d |  | start no earlier than 2012-11-23 09:00 |  | Sebastian Wilczewski | 2h | 160 | 160 |
| 83 | Budowa i zmiana lokalizacji-**.35 | Przygotowanie raportu 35 |  | 2h | 2012-11-30 09:00 | 2012-11-30 11:00 |  | 2012-11-30 09:00 | 2012-11-30 11:00 | 2h | 170.75d |  | start no earlier than 2012-11-30 09:00 |  | Sebastian Wilczewski | 2h | 160 | 160 |
| 84 | Budowa i zmiana lokalizacji-**.36 | Przygotowanie raportu 36 |  | 2h | 2012-12-07 09:00 | 2012-12-07 11:00 |  | 2012-12-07 09:00 | 2012-12-07 11:00 | 2h | 165.75d |  | start no earlier than 2012-12-07 09:00 |  | Sebastian Wilczewski | 2h | 160 | 160 |
| 85 | Budowa i zmiana lokalizacji-**.37 | Przygotowanie raportu 37 |  | 2h | 2012-12-14 09:00 | 2012-12-14 11:00 |  | 2012-12-14 09:00 | 2012-12-14 11:00 | 2h | 160.75d |  | start no earlier than 2012-12-14 09:00 |  | Sebastian Wilczewski | 2h | 160 | 160 |
| 86 | Budowa i zmiana lokalizacji-**.38 | Przygotowanie raportu 38 |  | 2h | 2012-12-21 09:00 | 2012-12-21 11:00 |  | 2012-12-21 09:00 | 2012-12-21 11:00 | 2h | 155.75d |  | start no earlier than 2012-12-21 09:00 |  | Sebastian Wilczewski | 2h | 160 | 160 |
| 87 | Budowa i zmiana lokalizacji-**.39 | Przygotowanie raportu 39 |  | 2h | 2012-12-28 09:00 | 2012-12-28 11:00 |  | 2012-12-28 09:00 | 2012-12-28 11:00 | 2h | 152.75d |  | start no earlier than 2012-12-28 09:00 |  | Sebastian Wilczewski | 2h | 160 | 160 |
| 88 | Budowa i zmiana lokalizacji-**.40 | Przygotowanie raportu 40 |  | 2h | 2013-01-04 09:00 | 2013-01-04 11:00 |  | 2013-01-04 09:00 | 2013-01-04 11:00 | 2h | 148.75d |  | start no earlier than 2013-01-04 09:00 |  | Sebastian Wilczewski | 2h | 160 | 160 |
| 89 | Budowa i zmiana lokalizacji-**.41 | Przygotowanie raportu 41 |  | 2h | 2013-01-11 09:00 | 2013-01-11 11:00 |  | 2013-01-11 09:00 | 2013-01-11 11:00 | 2h | 143.75d |  | start no earlier than 2013-01-11 09:00 |  | Sebastian Wilczewski | 2h | 160 | 160 |
| 90 | Budowa i zmiana lokalizacji-**.42 | Przygotowanie raportu 42 |  | 2h | 2013-01-18 09:00 | 2013-01-18 11:00 |  | 2013-01-18 09:00 | 2013-01-18 11:00 | 2h | 138.75d |  | start no earlier than 2013-01-18 09:00 |  | Sebastian Wilczewski | 2h | 160 | 160 |
| 91 | Budowa i zmiana lokalizacji-**.43 | Przygotowanie raportu 43 |  | 2h | 2013-01-25 09:00 | 2013-01-25 11:00 |  | 2013-01-25 09:00 | 2013-01-25 11:00 | 2h | 133.75d |  | start no earlier than 2013-01-25 09:00 |  | Sebastian Wilczewski | 2h | 160 | 160 |
| 92 | Budowa i zmiana lokalizacji-**.44 | Przygotowanie raportu 44 |  | 2h | 2013-02-01 09:00 | 2013-02-01 11:00 |  | 2013-02-01 09:00 | 2013-02-01 11:00 | 2h | 128.75d |  | start no earlier than 2013-02-01 09:00 |  | Sebastian Wilczewski | 2h | 160 | 160 |
| 93 | Budowa i zmiana lokalizacji-**.45 | Przygotowanie raportu 45 |  | 2h | 2013-02-08 09:00 | 2013-02-08 11:00 |  | 2013-02-08 09:00 | 2013-02-08 11:00 | 2h | 123.75d |  | start no earlier than 2013-02-08 09:00 |  | Sebastian Wilczewski | 2h | 160 | 160 |
| 94 | Budowa i zmiana lokalizacji-**.46 | Przygotowanie raportu 46 |  | 2h | 2013-02-15 09:00 | 2013-02-15 11:00 |  | 2013-02-15 09:00 | 2013-02-15 11:00 | 2h | 118.75d |  | start no earlier than 2013-02-15 09:00 |  | Sebastian Wilczewski | 2h | 160 | 160 |

| ID | WBS | Task | Type | Duration | Start | Finish | Predecessors | Baseline start | Baseline finish | Baseline duration | Total slack | Constraint | Deadline | Resources | Work | Cost | Baseline cost |
| --- | --- | --- | --- | --- | --- | --- | --- | --- | --- | --- | --- | --- | --- | --- | --- | --- | --- |
| 95 | Budowa i zmiana lokalizacji-**.47 | Przygotowanie raportu 47 |  | 2h | 2013-02-22 09:00 | 2013-02-22 11:00 |  | 2013-02-22 09:00 | 2013-02-22 11:00 | 2h | 113.75d | start no earlier than 2013-02-22 09:00 |  | Sebastian Wilczewski | 2h | 160 | 160 |
| 96 | Budowa i zmiana lokalizacji-**.48 | Przygotowanie raportu 48 |  | 2h | 2013-03-01 09:00 | 2013-03-01 11:00 |  | 2013-03-01 09:00 | 2013-03-01 11:00 | 2h | 108.75d | start no earlier than 2013-03-01 09:00 |  | Sebastian Wilczewski | 2h | 160 | 160 |
| 97 | Budowa i zmiana lokalizacji-**.49 | Przygotowanie raportu 49 |  | 2h | 2013-03-08 09:00 | 2013-03-08 11:00 |  | 2013-03-08 09:00 | 2013-03-08 11:00 | 2h | 103.75d | start no earlier than 2013-03-08 09:00 |  | Sebastian Wilczewski | 2h | 160 | 160 |
| 98 | Budowa i zmiana lokalizacji-**.50 | Przygotowanie raportu 50 |  | 2h | 2013-03-15 09:00 | 2013-03-15 11:00 |  | 2013-03-15 09:00 | 2013-03-15 11:00 | 2h | 98.75d | start no earlier than 2013-03-15 09:00 |  | Sebastian Wilczewski | 2h | 160 | 160 |
| 99 | Budowa i zmiana lokalizacji-**.51 | Przygotowanie raportu 51 |  | 2h | 2013-03-22 09:00 | 2013-03-22 11:00 |  | 2013-03-22 09:00 | 2013-03-22 11:00 | 2h | 93.75d | start no earlier than 2013-03-22 09:00 |  | Sebastian Wilczewski | 2h | 160 | 160 |
| 100 | Budowa i zmiana lokalizacji-**.52 | Przygotowanie raportu 52 |  | 2h | 2013-03-29 09:00 | 2013-03-29 11:00 |  | 2013-03-29 09:00 | 2013-03-29 11:00 | 2h | 88.75d | start no earlier than 2013-03-29 09:00 |  | Sebastian Wilczewski | 2h | 160 | 160 |
| 101 | Budowa i zmiana lokalizacji-**.53 | Przygotowanie raportu 53 |  | 2h | 2013-04-05 09:00 | 2013-04-05 11:00 |  | 2013-04-05 09:00 | 2013-04-05 11:00 | 2h | 83.75d | start no earlier than 2013-04-05 09:00 |  | Sebastian Wilczewski | 2h | 160 | 160 |
| 102 | Budowa i zmiana lokalizacji-**.54 | Przygotowanie raportu 54 |  | 2h | 2013-04-12 09:00 | 2013-04-12 11:00 |  | 2013-04-12 09:00 | 2013-04-12 11:00 | 2h | 78.75d | start no earlier than 2013-04-12 09:00 |  | Sebastian Wilczewski | 2h | 160 | 160 |
| 103 | Budowa i zmiana lokalizacji-**.55 | Przygotowanie raportu 55 |  | 2h | 2013-04-19 09:00 | 2013-04-19 11:00 |  | 2013-04-19 09:00 | 2013-04-19 11:00 | 2h | 73.75d | start no earlier than 2013-04-19 09:00 |  | Sebastian Wilczewski | 2h | 160 | 160 |
| 104 | Budowa i zmiana lokalizacji-**.56 | Przygotowanie raportu 56 |  | 2h | 2013-04-26 09:00 | 2013-04-26 11:00 |  | 2013-04-26 09:00 | 2013-04-26 11:00 | 2h | 68.75d | start no earlier than 2013-04-26 09:00 |  | Sebastian Wilczewski | 2h | 160 | 160 |
| 105 | Budowa i zmiana lokalizacji-**.57 | Przygotowanie raportu 57 |  | 2h | 2013-05-06 08:00 | 2013-05-06 10:00 |  | 2013-05-06 08:00 | 2013-05-06 10:00 | 2h | 64.88d | start no earlier than 2013-05-03 09:00 |  | Sebastian Wilczewski | 2h | 160 | 160 |
| 106 | Budowa i zmiana lokalizacji-**.58 | Przygotowanie raportu 58 |  | 2h | 2013-05-10 09:00 | 2013-05-10 11:00 |  | 2013-05-10 09:00 | 2013-05-10 11:00 | 2h | 60.75d | start no earlier than 2013-05-10 09:00 |  | Sebastian Wilczewski | 2h | 160 | 160 |
| 107 | Budowa i zmiana lokalizacji-**.59 | Przygotowanie raportu 59 |  | 2h | 2013-05-17 09:00 | 2013-05-17 11:00 |  | 2013-05-17 09:00 | 2013-05-17 11:00 | 2h | 55.75d | start no earlier than 2013-05-17 09:00 |  | Sebastian Wilczewski | 2h | 160 | 160 |
| 108 | Budowa i zmiana lokalizacji-**.60 | Przygotowanie raportu 60 |  | 2h | 2013-05-24 09:00 | 2013-05-24 11:00 |  | 2013-05-24 09:00 | 2013-05-24 11:00 | 2h | 50.75d | start no earlier than 2013-05-24 09:00 |  | Sebastian Wilczewski | 2h | 160 | 160 |
| 109 | Budowa i zmiana lokalizacji-**.61 | Przygotowanie raportu 61 |  | 2h | 2013-05-31 09:00 | 2013-05-31 11:00 |  | 2013-05-31 09:00 | 2013-05-31 11:00 | 2h | 45.75d | start no earlier than 2013-05-31 09:00 |  | Sebastian Wilczewski | 2h | 160 | 160 |
| 110 | Budowa i zmiana lokalizacji-** | Wprowadzanie poprawek | inactive, manual | 1d? | 2013-08-06 08:00 | 2013-08-06 16:00 |  |  |  |  |  |  |  |  |  |  | -0 |
| 111 | Budowa i zmiana lokalizacji-** | Koniec | milestone | 0d | 2013-08-07 09:00 | 2013-08-07 09:00 | 47 | 2013-08-07 09:00 | 2013-08-07 09:00 | 0d | 0d | finish no later than 2013-09-30 16:00 | 2013-09-30 16:00 |  |  |  |  |
